Schedule from MS Project XML, 2017-02-01 to 2023-01-09.

## Calendars

- Standard: Mon-Sun 08:00-12:00, 13:00-17:00.

## Schedule

| ID | WBS | Task | Type | Duration | Start | Finish | Predecessors |
| --- | --- | --- | --- | --- | --- | --- | --- |
| 1 | 1 | Start of Bunker Access | milestone, manual | 0d | 2019-11-01 | 2019-11-01 |  |
| 2 | 2 | End of Bunker Access | milestone, manual | 0d | 2020-05-01 | 2020-05-01 |  |
| 3 | 3 | Access to E02-2 | milestone, manual | 0d | 2019-10-15 | 2019-10-15 |  |
| 4 | 4 | Access to E02-1 | milestone, manual | 0d | 2019-04-27 | 2019-04-27 |  |
| 5 | 5 | Access to E01 | milestone, manual | 0d | 2019-04-27 | 2019-04-27 |  |
| 6 | 6 | TG2 | milestone, manual | 0d | 2017-02-01 | 2017-02-01 |  |
| 7 | 7 | TG3 | milestone, manual | 0d | 2018-02-01 | 2018-02-01 |  |
| 8 | 8 | TG4 | milestone, manual | 0d | 2019-10-01 | 2019-10-01 |  |
| 9 | 9 | TG5 | milestone, manual | 0d | 2022-01-10 | 2022-01-10 |  |
| 10 | 10 | **BEER** |  | 2141d | 2017-03-01 | 2023-01-09 |  |
| 11 | 10.1 | Cold commissioning | manual | 129d | 2021-09-01 | 2022-01-07 |  |
| 12 | 10.2 | Hot commissioning | manual | 365d | 2022-01-10 | 2023-01-09 | 9 |
| 13 | 10.3 | **Cave** |  | 1665d | 2017-03-01 | 2021-09-20 |  |
| 14 | 10.3.1 | RP cave | milestone, manual | 0d | 2018-03-01 | 2018-03-01 | 15 |
| 15 | 10.3.2 | Design | manual | 365d | 2017-03-01 | 2018-02-28 |  |
| 16 | 10.3.3 | RI cave | milestone, manual | 0d | 2020-05-26 | 2020-05-26 |  |
| 17 | 10.3.4 | **Cave shielding** |  | 543d | 2019-07-01 | 2020-12-24 |  |
| 18 | 10.3.4.1 | Procurement&Fabrication | manual | 420d | 2019-07-01 | 2020-08-23 | 15 |
| 19 | 10.3.4.2 | Installation&Integration | manual | 120d | 2020-08-27 | 2020-12-24 | 18 |
| 20 | 10.3.5 | **Cave platform** |  | 332d | 2019-09-27 | 2020-08-23 |  |
| 21 | 10.3.5.1 | Procurement&Fabrication | manual | 240d | 2019-09-27 | 2020-05-23 | 15 |
| 22 | 10.3.5.2 | Installation&Integration | manual | 90d | 2020-05-26 | 2020-08-23 | 16, 21 |
| 23 | 10.3.6 | **Guide exchanger** |  | 1057d | 2018-10-30 | 2021-09-20 |  |
| 24 | 10.3.6.1 | Design | manual | 180d | 2018-10-30 | 2019-04-27 |  |
| 25 | 10.3.6.2 | Procurement&Fabrication | manual | 301d | 2019-05-01 | 2020-02-25 | 24 |
| 26 | 10.3.6.3 | Installation&Integration | manual | 270d | 2020-12-25 | 2021-09-20 | 25, 19 |

Notes:
- 11: Testing of an integrity of the whole instrument.
- 13: NPI
- 14: Readiness for cave procurement
- 16: Experiment cave ready to install.
- 18: 120 days of procurement / 10 months for fabrication
- 21: 120 days of procurement / 4 months for manufacturing on site
- 25: 120 of procurement / 6 months of manufacturing

| ID | WBS | Task | Type | Duration | Start | Finish | Predecessors |
| --- | --- | --- | --- | --- | --- | --- | --- |
| 27 | 10.4 | **Cave equipement** |  | 1563d | 2017-09-16 | 2021-12-26 |  |
| 28 | 10.4.1 | RP MCA | milestone, manual | 0d | 2018-08-02 | 2018-08-02 | 29 |
| 29 | 10.4.2 | Design | manual | 320d | 2017-09-16 | 2018-08-01 |  |
| 30 | 10.4.3 | Procurement&Fabrication | manual | 390d | 2019-12-01 | 2020-12-24 | 29 |
| 31 | 10.4.4 | Installation&Integration | manual | 367d | 2020-12-25 | 2021-12-26 | 30, 19 |
| 32 | 10.5 | **Hutch** |  | 1296d | 2017-12-05 | 2021-06-22 |  |
| 33 | 10.5.1 | RP hutch | milestone, manual | 0d | 2018-07-03 | 2018-07-03 | 34 |
| 34 | 10.5.2 | Design | manual | 210d | 2017-12-05 | 2018-07-02 |  |
| 35 | 10.5.3 | Procurement&Fabrication | manual | 370d | 2019-03-23 | 2020-03-26 | 34 |
| 36 | 10.5.4 | RI hutch | milestone, manual | 0d | 2021-01-24 | 2021-01-24 |  |
| 37 | 10.5.5 | Installation&Integration | manual | 150d | 2021-01-24 | 2021-06-22 | 26SS+30d, 35, 36 |
| 38 | 10.6 | **Optics** |  | 1474d | 2017-03-01 | 2021-03-13 |  |
| 39 | 10.6.1 | **Insert** |  | 744d | 2017-03-01 | 2019-03-14 |  |
| 40 | 10.6.1.1 | Insert installed | milestone, manual | 0d | 2019-03-15 | 2019-03-15 | 44 |
| 41 | 10.6.1.2 | RP insert | milestone, manual | 0d | 2017-09-01 | 2017-09-01 | 42 |
| 42 | 10.6.1.3 | Insert-Desing | manual | 184d | 2017-03-01 | 2017-08-31 |  |
| 43 | 10.6.1.4 | Procurement&Fabrication | manual | 260d | 2017-09-01 | 2018-05-18 | 42 |
| 44 | 10.6.1.5 | Installation&Integration | manual | 60d | 2019-01-14 | 2019-03-14 |  |
| 45 | 10.6.2 | **Transport section** |  | 1274d | 2017-03-01 | 2020-08-25 |  |
| 46 | 10.6.2.1 | Transport-section design | manual | 220d | 2017-03-01 | 2017-10-06 |  |
| 47 | 10.6.2.2 | Procurement&Fabrication | manual | 720d | 2017-10-11 | 2019-09-30 | 46 |
| 48 | 10.6.2.3 | RI optics | milestone, manual | 0d | 2019-10-01 | 2019-10-01 |  |
| 49 | 10.6.2.4 | Installation&Integration | manual | 330d | 2019-10-01 | 2020-08-25 | 47, 48 |
| 50 | 10.6.3 | RP optics and shielding | milestone, manual | 0d | 2018-03-01 | 2018-03-01 | 52, 70, 65 |

Notes:
- 27: NPI / Include - sample positioning system, accessories, echangable focussing section, slits, etc. MCA included here.
- 28: Readiness for MCA procurement.
- 30: 6 months for delivery and 4 months for procurement.
- 32: NPI
- 33: Readiness for hutch procurement
- 36: Control hutch ready to install.
- 37: Related to the cave installation and delayed 30 days after cave installation start.
- 39: HZG
- 41: Readiness for insert procurement
- 42: Final design starts as Phase 2. / Finish in Q3 2017.
- 43: Fabrication is about 130 days - 2-3 week/m for 6 meters. / Procurement is same 130 days. / Delivery 1 month before installation. / Installation Q1 2019.
- 44: Installation and allignment - 60 days
- 45: NPI
- 47: 120 meters of guide - 18 month - 540 days. / 120 days of procurement / 2 months reserve
- 48: Neutron optics outside the bunker ready to install.
- 49: 330 days of installation and alignement. Expected installation from cave to bunker because E02-1 (closer to E01 - 27/4/2019) will be accessible before E02-2 (15/10/2019).
- 50: Readiness for optics and shielding procurement

| ID | WBS | Task | Type | Duration | Start | Finish | Predecessors |
| --- | --- | --- | --- | --- | --- | --- | --- |
| 51 | 10.6.4 | **Bunker section** |  | 1157d | 2017-03-01 | 2020-04-30 |  |
| 52 | 10.6.4.1 | Bunker-guide Design | manual | 365d | 2017-03-01 | 2018-02-28 |  |
| 53 | 10.6.4.2 | Procurement&Fabrication | manual | 600d | 2018-03-01 | 2019-10-21 | 52 |
| 54 | 10.6.4.3 | RI optics | milestone, manual | 0d | 2019-11-01 | 2019-11-01 |  |
| 55 | 10.6.4.4 | Installation&Integration | manual | 182d | 2019-11-01 | 2020-04-30 | 53, 54, 2FF, 1 |
| 56 | 10.6.5 | **Bunker througput** |  | 633d | 2018-01-05 | 2019-09-29 |  |
| 57 | 10.6.5.1 | Design | manual | 120d | 2018-01-05 | 2018-05-04 |  |
| 58 | 10.6.5.2 | Procurement&Fabrication | manual | 270d | 2018-11-04 | 2019-07-31 | 57 |
| 59 | 10.6.5.3 | Installation&Integration | manual | 60d | 2019-08-01 | 2019-09-29 | 58 |
| 60 | 10.6.6 | **Secondary shutter** |  | 960d | 2017-12-04 | 2020-07-20 |  |
| 61 | 10.6.6.1 | Design | manual | 180d | 2017-12-04 | 2018-06-01 |  |
| 62 | 10.6.6.2 | Procurement&Manufacturing | manual | 225d | 2019-06-19 | 2020-01-29 | 61 |
| 63 | 10.6.6.3 | Installation&Integration | manual | 173d | 2020-01-30 | 2020-07-20 | 62 |
| 64 | 10.6.7 | **Focusing section** |  | 1225d | 2017-11-05 | 2021-03-13 |  |
| 65 | 10.6.7.1 | Focusing Design | manual | 115d | 2017-11-05 | 2018-02-27 |  |
| 66 | 10.6.7.2 | Procurement&Fabrication | manual | 410d | 2019-07-13 | 2020-08-25 | 65 |
| 67 | 10.6.7.3 | RI focusing | milestone, manual | 0d | 2020-08-26 | 2020-08-26 |  |
| 68 | 10.6.7.4 | Installation&Integration | manual | 200d | 2020-08-26 | 2021-03-13 | 49FS-60d, 66, 67 |
| 69 | 10.7 | **Guide shielding** |  | 1523d | 2017-03-01 | 2021-05-01 |  |
| 70 | 10.7.1 | Design | manual | 365d | 2017-03-01 | 2018-02-28 |  |
| 71 | 10.7.2 | Procurement&Fabrication | manual | 500d | 2018-03-01 | 2019-07-13 | 70 |
| 72 | 10.7.3 | RI shielding | milestone, manual | 0d | 2019-11-20 | 2019-11-20 |  |
| 73 | 10.7.4 | Installation&Integration | manual | 529d | 2019-11-20 | 2021-05-01 | 71, 49SS+20d, 72 |
| 74 | 10.8 | **Choppers** |  | 1427d | 2017-03-01 | 2021-01-25 |  |
| 75 | 10.8.1 | **Choppers inside the bunker** |  | 1157d | 2017-03-01 | 2020-04-30 |  |
| 76 | 10.8.1.1 | RP choppers | milestone, manual | 0d | 2017-11-07 | 2017-11-07 | 77 |
| 77 | 10.8.1.2 | Design | manual | 251d | 2017-03-01 | 2017-11-06 |  |
| 78 | 10.8.1.3 | Procurement&Fabrication | manual | 690d | 2017-12-16 | 2019-11-05 | 77 |
| 79 | 10.8.1.4 | RI choppers | milestone, manual | 0d | 2019-12-03 | 2019-12-03 |  |
| 80 | 10.8.1.5 | Installation&Integration | manual | 150d | 2019-12-03 | 2020-04-30 | 78, 55SS+20d, 79, 2FF, 1 |

Notes:
- 51: HZG
- 53: 22 meters of guide - 2-3 weeks/m - 380 days. / 120 days of procurement / 3 months reserve + shipement
- 54: Neutron optics inside the bunker ready to install.
- 55: Installation can't start before 1/11/2019 - crane access to D03
- 58: 120 days of procurement / 150 days of fabrication
- 59: Bunker waal will be installed Aug/2019
- 62: 120 days of procurement / 150 days of manufacturing
- 63: Need to be finished before BOT
- 64: NPI
- 66: 13 meters of focussing guide - 2-3weeks/m - 230 days. / 120 days of procurement / 2 months reserve
- 67: Neutron optics inside experimental cave ready to install.
- 68: Related to installation end of transport part and can start 30 days before end of transport part.
- 69: NPI
- 71: Transport not included
- 72: Guide shielding ready to install.
- 73: Expecting the installation in line with the guide. / Start of installation with 30 days delay.
- 74: HZG
- 76: Readiness for choppers procurement
- 78: 120 days of procurement / 4 month per chopper * 4 choppers = 18 months / Plus 30 days reserve.
- 79: Choppers inside the bunker ready to install-
- 80: Need to be coordinated with the bunker guide system. / Expected start 20 days after start of guide installation. / Need to be finished before May/2020

| ID | WBS | Task | Type | Duration | Start | Finish | Predecessors |
| --- | --- | --- | --- | --- | --- | --- | --- |
| 81 | 10.8.2 | **Chopper after the bunker** |  | 1302d | 2017-07-04 | 2021-01-25 |  |
| 82 | 10.8.2.1 | Design | manual | 218d | 2017-07-04 | 2018-02-06 |  |
| 83 | 10.8.2.2 | Procurement&Fabrication | manual | 240d | 2019-12-03 | 2020-07-29 | 82 |
| 84 | 10.8.2.3 | RI choppers | milestone, manual | 0d | 2020-07-30 | 2020-07-30 |  |
| 85 | 10.8.2.4 | Installation&Integration | manual | 180d | 2020-07-30 | 2021-01-25 | 49SS+90d, 83, 84 |
| 86 | 10.9 | **Detectors** |  | 1673d | 2017-03-01 | 2021-09-28 |  |
| 87 | 10.9.1 | RP detectors | milestone, manual | 0d | 2018-08-02 | 2018-08-02 | 88 |
| 88 | 10.9.2 | Design | manual | 519d | 2017-03-01 | 2018-08-01 |  |
| 89 | 10.9.3 | Procurement&Fabrication | manual | 500d | 2019-08-19 | 2020-12-30 | 88 |
| 90 | 10.9.4 | RI detectors | milestone, manual | 0d | 2021-01-02 | 2021-01-02 |  |
| 91 | 10.9.5 | Installation&Integration | manual | 270d | 2021-01-02 | 2021-09-28 | 89, 90, 19 |
| 92 | 10.10 | **MCA** |  | 1627d | 2017-03-01 | 2021-08-13 |  |
| 93 | 10.10.1 | Design | manual | 427d | 2017-03-01 | 2018-05-01 |  |
| 94 | 10.10.2 | Procurement&Fabrication | manual | 431d | 2018-10-01 | 2019-12-05 | 93 |
| 95 | 10.10.3 | Installation&Integration | manual | 617d | 2019-12-06 | 2021-08-13 | 94 |

Notes:
- 83: 120 days of procurement / 3 month per chopper
- 84: Chopper outside the bunker ready to install.
- 85: Installation coordinated with the transport guide -> / delay in installation 3 month after guide installation start.
- 86: HZG
- 87: Readiness for detectors procurement
- 89: 120 days of procurement / 6 months per detector (detector + portal + colimators) * 2 detectors = 12 month
- 90: Detectors ready to install.
- 91: Related with cave installation finished. Start 20 days later that the cave is finished.
